# Residential Construction 1

How a schedule from MS Project changed from version to version. A marks actual dates.

## Version 1 (saved 2015-12-10, file Residential Construction.mpp)

| ID | WBS | Task | Duration | Start | Finish | Predecessors | Total float |
| --- | --- | --- | --- | --- | --- | --- | --- |
| 1 | 1 | **General Conditions** | 21d | 2017-07-10 | 2017-08-07 |  | 0d |
| 2 |  | Finalize plans and develop estimate with owner, architect | 20d | 2017-07-10 | 2017-08-04 |  | 0d |
| 3 |  | Sign contract and notice to proceed | 1d | 2017-08-07 | 2017-08-07 | 2 | 0d |
| 4 | 1.3 | **Apply for Permits** | 0d | 2017-08-07 | 2017-08-07 |  | 0d |
| 5 |  | Secure foundation permit | 0d | 2017-08-07 | 2017-08-07 | 3 | 0d |
| 6 |  | Secure framing permit | 0d | 2017-08-07 | 2017-08-07 | 3 | 0d |
| 7 |  | Secure electrical permit | 0d | 2017-08-07 | 2017-08-07 | 3 | 0d |
| 8 |  | Secure plumbing permit | 0d | 2017-08-07 | 2017-08-07 | 3 | 0d |
| 9 |  | Secure HVAC permit | 0d | 2017-08-07 | 2017-08-07 | 3 | 0d |
| 10 |  | Secure miscellaneous permits | 0d | 2017-08-07 | 2017-08-07 | 3 | 0d |
| 11 | 2 | **Site Work** | 3d | 2017-08-08 | 2017-08-10 |  | 0d |
| 12 |  | Clear and grub lot | 1d | 2017-08-08 | 2017-08-08 | 5, 6, 7, 8, 10, 9 | 0d |
| 13 |  | Install temporary power service | 1d | 2017-08-09 | 2017-08-09 | 12 | 0d |
| 14 |  | Install underground utilities | 1d | 2017-08-10 | 2017-08-10 | 13 | 0d |
| 15 | 3 | **Foundation** | 42d | 2017-08-11 | 2017-10-09 |  | 0d |
| 16 |  | Excavate for foundations | 3d | 2017-08-11 | 2017-08-15 | 14 | 0d |
| 17 |  | Form basement walls | 13d | 2017-08-16 | 2017-09-01 | 16 | 0d |
| 18 |  | Place concrete for foundations & basement walls | 12d | 2017-09-04 | 2017-09-19 | 17 | 0d |
| 19 |  | Cure basement walls for 7 days | 7d | 2017-09-20 | 2017-09-28 | 18 | 0d |
| 20 |  | Strip basement wall forms | 2d | 2017-09-29 | 2017-10-02 | 19 | 0d |
| 21 |  | Waterproof/insulate basement walls | 2d | 2017-10-03 | 2017-10-04 | 20 | 0d |
| 22 |  | Perform foundation inspection | 1d | 2017-10-05 | 2017-10-05 | 21, 16 | 0d |
| 23 |  | Backfill foundation | 2d | 2017-10-06 | 2017-10-09 | 22 | 0d |
| 24 | 4 | **Framing** | 22d | 2017-10-10 | 2017-11-08 |  | 0d |
| 25 |  | Install 1st floor joists | 2d | 2017-10-10 | 2017-10-11 | 23 | 0d |
| 26 |  | Lay 1st floor decking | 2d | 2017-10-12 | 2017-10-13 | 25 | 0d |
| 27 |  | Frame 1st floor walls | 4d | 2017-10-16 | 2017-10-19 | 26 | 0d |
| 28 |  | Frame 1st floor corners | 1d | 2017-10-20 | 2017-10-20 | 27 | 0d |
| 29 |  | Install 2nd floor joists | 2d | 2017-10-23 | 2017-10-24 | 28 | 0d |
| 30 |  | Frame 2nd floor decking | 2d | 2017-10-25 | 2017-10-26 | 29 | 0d |
| 31 |  | Frame 2nd floor walls | 3d | 2017-10-27 | 2017-10-31 | 30 | 0d |
| 32 |  | Frame 2nd floor corners | 2d | 2017-11-01 | 2017-11-02 | 31 | 0d |
| 33 |  | Complete roof framing | 3d | 2017-11-03 | 2017-11-07 | 32 | 0d |
| 34 |  | Conduct framing inspection | 1d | 2017-11-08 | 2017-11-08 | 33 | 0d |
| 35 | 5 | **Dry In** | 22d | 2017-11-08 | 2017-12-07 |  | 0d |
| 36 |  | Install 1st floor sheathing | 3d | 2017-11-09 | 2017-11-13 | 34 | 0d |
| 37 |  | Install 2nd floor sheathing | 3d | 2017-11-14 | 2017-11-16 | 36 | 0d |
| 38 |  | Install roof decking | 3d | 2017-11-08 | 2017-11-10 | 33 | 4d |
| 39 |  | Install felt, flashing and shingles | 3d | 2017-11-24 | 2017-11-28 | 47 | 0d |
| 40 |  | Hang 1st floor exterior doors | 1d | 2017-11-29 | 2017-11-29 | 39 | 0d |
| 41 |  | Install 1st floor windows | 3d | 2017-11-30 | 2017-12-04 | 40 | 0d |
| 42 |  | Install 2nd floor windows | 3d | 2017-12-05 | 2017-12-07 | 41 | 0d |
| 43 | 6 | **Exterior Finishes** | 19d | 2017-12-08 | 2018-01-03 |  | 5d |
| 44 |  | Complete exterior brick | 16d | 2017-12-08 | 2017-12-29 | 42 | 5d |
| 45 |  | Complete exterior siding | 3d | 2018-01-01 | 2018-01-03 | 44 | 5d |
| 46 | 7 | **Utility Rough-B97Ins and Complete Concrete** | 21d | 2017-11-13 | 2017-12-11 |  | 4d |
| 47 |  | Rough-in plumbing | 5d | 2017-11-17 | 2017-11-23 | 38, 37 | 0d |
| 48 |  | Conduct rough-in plumbing inspection | 1d | 2017-11-24 | 2017-11-24 | 47 | 20d |
| 49 |  | Place concrete for basement floor | 11d | 2017-11-27 | 2017-12-11 | 48 | 33d |
| 50 |  | Rough-in electrical | 5d | 2017-11-17 | 2017-11-23 | 38, 37 | 6d |
| 51 |  | Conduct rough-in electrical inspection | 1d | 2017-11-24 | 2017-11-24 | 50 | 6d |
| 52 |  | Rough-in HVAC | 3d | 2017-11-27 | 2017-11-29 | 51 | 6d |
| 53 |  | Conduct rough-in HVAC inspection | 1d | 2017-11-30 | 2017-11-30 | 52 | 24d |
| 54 |  | Rough-in communication - phone, cable, computer, alarm | 2d | 2017-11-13 | 2017-11-14 | 38 | 17d |
| 55 | 8 | **Interior Finishes** | 30d | 2017-12-08 | 2018-01-18 |  | 0d |
| 56 | 8.1 | **Insulation** | 11d | 2017-12-08 | 2017-12-22 |  | 0d |
| 57 |  | Place wall insulation - 1st floor | 1d | 2017-12-08 | 2017-12-08 | 36, 42, 54, 52, 50, 37 | 0d |
| 58 |  | Place wall insulation - 2nd floor | 1d | 2017-12-11 | 2017-12-11 | 57 | 27d |
| 59 |  | Place ceiling insulation - 2nd floor | 1d | 2017-12-21 | 2017-12-21 | 65, 58 | 24d |
| 60 |  | Conduct insulation inspection | 1d | 2017-12-22 | 2017-12-22 | 59 | 24d |
| 61 | 8.2 | **Drywall** | 9d | 2017-12-11 | 2017-12-21 |  | 0d |
| 62 |  | Install drywall - 1st floor walls | 2d | 2017-12-11 | 2017-12-12 | 57 | 0d |
| 63 |  | Install drywall - 1st floor overhead | 2d | 2017-12-13 | 2017-12-14 | 62 | 0d |
| 64 |  | Install drywall 2nd floor walls | 2d | 2017-12-15 | 2017-12-18 | 63, 58 | 24d |
| 65 |  | Install drywall 2nd floor overhead | 2d | 2017-12-19 | 2017-12-20 | 64 | 24d |
| 66 |  | Tape and float 1st floor drywall | 1d | 2017-12-15 | 2017-12-15 | 63 | 0d |
| 67 |  | Tape and float 2nd floor drywall | 1d | 2017-12-21 | 2017-12-21 | 65, 66 | 33d |
| 68 | 8.3 | **Paint and Wallpaper** | 17d | 2017-12-18 | 2018-01-09 |  | 0d |
| 69 |  | Texture all except entry and kitchen - 1st floor | 1d | 2017-12-18 | 2017-12-18 | 66 | 0d |
| 70 |  | Paint all except entry and kitchen - 1st floor | 1d | 2017-12-19 | 2017-12-19 | 69 | 0d |

| ID | WBS | Task | Duration | Start | Finish | Predecessors | Total float |
| --- | --- | --- | --- | --- | --- | --- | --- |
| 71 |  | Hang wallpaper entry and kitchen - 1st floor | 1d | 2017-12-20 | 2017-12-20 | 70 | 0d |
| 72 |  | Texture all - 2nd floor | 1d | 2017-12-19 | 2017-12-19 | 69 | 34d |
| 73 |  | Paint all - 2nd floor | 1d | 2017-12-20 | 2017-12-20 | 72 | 34d |
| 74 |  | Paint exterior siding & trim work | 4d | 2018-01-04 | 2018-01-09 | 45 | 5d |
| 75 | 8.4 | **Cabinets** | 6d | 2017-12-21 | 2017-12-28 |  | 0d |
| 76 |  | Install 1st floor - kitchen cabinets | 2d | 2017-12-21 | 2017-12-22 | 71 | 0d |
| 77 |  | Install 1st floor - master bath and guest cabinets | 1d | 2017-12-25 | 2017-12-25 | 76 | 0d |
| 78 |  | Install 2nd floor - hall bath and private bath cabinets | 1d | 2017-12-26 | 2017-12-26 | 77 | 1d |
| 79 |  | Install chair rails, crown moldings, trim | 2d | 2017-12-27 | 2017-12-28 | 78 | 20d |
| 80 | 8.5 | **Finish Plumbing** | 6d | 2017-12-25 | 2018-01-01 |  | 0d |
| 81 |  | Complete 1st floor - kitchen plumbing | 1d | 2017-12-25 | 2017-12-25 | 76, 48 | 0d |
| 82 |  | Complete 1st floor - master bath and guest plumbing | 2d | 2017-12-26 | 2017-12-27 | 81, 77 | 0d |
| 83 |  | Complete 2nd floor - hall bath and private bath plumbing | 2d | 2017-12-28 | 2017-12-29 | 82, 78 | 0d |
| 84 |  | Conduct finish plumbing inspection | 1d | 2018-01-01 | 2018-01-01 | 83 | 0d |
| 85 | 8.6 | **Finish Electrical** | 3d | 2018-01-01 | 2018-01-03 |  | 1d |
| 86 |  | Complete 1st floor circuits to service panel | 1d | 2018-01-01 | 2018-01-01 | 83, 51 | 3d |
| 87 |  | Complete 2nd floor circuits to service panel | 1d | 2018-01-02 | 2018-01-02 | 86 | 3d |
| 88 |  | Conduct finish electrical inspection | 1d | 2018-01-03 | 2018-01-03 | 87 | 3d |
| 89 |  | Complete communications wiring - phone, cable, computer, alarm | 2d | 2018-01-02 | 2018-01-03 | 84 | 0d |
| 90 | 8.7 | **Finish HVAC** | 3d | 2018-01-04 | 2018-01-08 |  | 0d |
| 91 |  | Complete 1st floor - zone 1 HVAC | 1d | 2018-01-04 | 2018-01-04 | 89, 53 | 0d |
| 92 |  | Complete 2nd floor - zone 2 HVAC | 1d | 2018-01-05 | 2018-01-05 | 91 | 0d |
| 93 |  | Conduct HVAC inspection | 1d | 2018-01-08 | 2018-01-08 | 92 | 0d |
| 94 | 8.8 | **Carpet, Tile and Appliances** | 8d | 2018-01-09 | 2018-01-18 |  | 0d |
| 95 |  | Tile entry, kitchen and baths | 3d | 2018-01-09 | 2018-01-11 | 88, 93 | 0d |
| 96 |  | Carpet 1st floor | 2d | 2018-01-12 | 2018-01-15 | 95 | 0d |
| 97 |  | Carpet 2nd floor | 2d | 2018-01-16 | 2018-01-17 | 96 | 0d |
| 98 |  | Install appliances | 1d | 2018-01-18 | 2018-01-18 | 97 | 0d |
| 99 | 9 | **Landscaping and Grounds Work** | 12d | 2018-01-10 | 2018-01-25 |  | 0d |
| 100 |  | Pour concrete driveway and sidewalks | 2d | 2018-01-10 | 2018-01-11 | 74 | 5d |
| 101 |  | Install backyard fence | 2d | 2018-01-19 | 2018-01-22 | 98, 100 | 0d |
| 102 |  | Sod and complete plantings - front yard | 2d | 2018-01-23 | 2018-01-24 | 101 | 0d |
| 103 |  | Sod and complete plantings - backyard | 1d | 2018-01-25 | 2018-01-25 | 102 | 0d |
| 104 | 10 | **Final Acceptance** | 8d | 2018-01-26 | 2018-02-06 |  | 0d |
| 105 |  | Complete final inspection for certificate of occupancy | 1d | 2018-01-26 | 2018-01-26 | 103, 93, 88, 84, 60, 79, 49 | 0d |
| 106 |  | Cleanup for occupancy | 1d | 2018-01-29 | 2018-01-29 | 98, 105 | 0d |
| 107 |  | Perform final walk-through inspection | 1d | 2018-01-30 | 2018-01-30 | 106 | 0d |
| 108 |  | Complete punch list items | 5d | 2018-01-31 | 2018-02-06 | 107 | 0d |

## Version 2 (data date 2016-09-23, saved 2016-02-07, file Woods_3BR_Home_Project_Customizing.mpp)

Last finish 2018-02-06 → 2016-12-30 (-403d). Complete tasks 0 → 33.

Added:

| ID | Task | Duration | Start | Finish | Predecessors | Constraint | Resources |
| --- | --- | --- | --- | --- | --- | --- | --- |
| 4 | **Clear Old Home** | 24d? | 2016-06-01 A | 2016-07-05 A |  |  |  |
| 5 | Demolition of Old House | 2w? | 2016-06-01 A | 2016-06-14 A | 3FS+2w |  | Site excavation contractor |
| 6 | Place Containers | 1d | 2016-06-01 A | 2016-06-01 A | 5SS |  | Container [300%]; Volunteer 4 |
| 7 | Sort Debris | 6.06d | 2016-06-09 A | 2016-06-17 A | 6, 5FF+1d |  | Volunteer 1; Volunteer 2; Volunteer 3; Volunteer 4; Container [300%] |
| 8 | Haul Recycling | 1d | 2016-07-05 A | 2016-07-05 A | 7 | start no earlier than 2016-07-05 | Container; Volunteer 4 |
| 9 | Haul Waste | 1d | 2016-06-17 A | 2016-06-20 A | 7 |  | Container; Volunteer 4; Waste Dump Fee [30 ton] |
| 46 | Install master bath skylight | 1d | 2016-10-19 | 2016-10-19 | 45 |  |  |
| 109 | Order Plants and Trees | 1d | 2016-12-07 | 2016-12-07 | 108 |  | Gary Clark |
| 110 | Build Compost Bin | 1d | 2016-12-08 | 2016-12-08 | 109 |  | Gary Clark |
| 111 | Build Flower Beds and Edges | 2d | 2016-12-12 | 2016-12-13 | 110 |  | Gary Clark |
| 112 | Weed and Trim Existing Yard | 2d | 2016-12-14 | 2016-12-15 | 111 |  | Gary Clark |
| 113 | Plant New Plants and Trees | 2d | 2016-12-19 | 2016-12-20 | 112 |  | Gary Clark |
| 114 | Re-Seed Bare Lawn Areas | 1d | 2016-12-21 | 2016-12-21 | 113 |  | Gary Clark |
| 120 | Ready for Move-In | 0d | 2016-12-30 | 2016-12-30 | 119 |  |  |

Removed: 102 Sod and complete plantings - front yard; 103 Sod and complete plantings - backyard

Changed:

| ID | Task | Start | Finish | Duration | Complete | Total float | Predecessors | Other |
| --- | --- | --- | --- | --- | --- | --- | --- | --- |
| 1 | **General Conditions** | 2017-07-10 → 2016-05-02 A (-434d) | 2017-08-07 → 2016-07-05 A (-398d) | 21d → 45d? | 0% → 100% | 0d → none |  | resources none → Construction Fixed Cost [0.1%]; baseline start none → 2016-05-02; baseline finish none → 2016-07-05 |
| 2 | Finalize plans and develop estimate with owner, architect | 2017-07-10 → 2016-05-02 A (-434d) | 2017-08-04 → 2016-05-13 A (-448d) | 20d → 10d | 0% → 100% | 0d → none |  | baseline start none → 2016-05-02; baseline finish none → 2016-05-13 |
| 3 | Sign contract and notice to proceed | 2017-08-07 → 2016-05-16 A (-448d) | 2017-08-07 → 2016-05-16 A (-448d) |  | 0% → 100% | 0d → none |  | baseline start none → 2016-05-16; baseline finish none → 2016-05-16 |
| 10 | **Apply for Permits** | 2017-08-07 → 2016-05-16 A (-448d) | 2017-08-07 → 2016-05-27 A (-437d) | 0d → 9d | 0% → 100% | 0d → none |  | baseline start none → 2016-05-16; baseline finish none → 2016-05-16 |
| 11 | Secure foundation permit | 2017-08-07 → 2016-05-16 A (-448d) | 2017-08-07 → 2016-05-27 A (-437d) |  | 0% → 100% | 0d → none |  | baseline start none → 2016-05-16; baseline finish none → 2016-05-16 |
| 12 | Secure framing permit | 2017-08-07 → 2016-05-16 A (-448d) | 2017-08-07 → 2016-05-27 A (-437d) |  | 0% → 100% | 0d → none |  | baseline start none → 2016-05-16; baseline finish none → 2016-05-16 |
| 13 | Secure electrical permit | 2017-08-07 → 2016-05-16 A (-448d) | 2017-08-07 → 2016-05-27 A (-437d) |  | 0% → 100% | 0d → none |  | baseline start none → 2016-05-16; baseline finish none → 2016-05-16 |
| 14 | Secure plumbing permit | 2017-08-07 → 2016-05-16 A (-448d) | 2017-08-07 → 2016-05-27 A (-437d) |  | 0% → 100% | 0d → none |  | baseline start none → 2016-05-16; baseline finish none → 2016-05-16 |
| 15 | Secure HVAC permit | 2017-08-07 → 2016-05-16 A (-448d) | 2017-08-07 → 2016-05-27 A (-437d) |  | 0% → 100% | 0d → none |  | baseline start none → 2016-05-16; baseline finish none → 2016-05-16 |
| 16 | Secure miscellaneous permits | 2017-08-07 → 2016-05-16 A (-448d) | 2017-08-07 → 2016-05-27 A (-437d) |  | 0% → 100% | 0d → none |  | baseline start none → 2016-05-16; baseline finish none → 2016-05-16 |
| 17 | **Site Work** | 2017-08-08 → 2016-07-06 A (-398d) | 2017-08-10 → 2016-07-08 A (-398d) |  | 0% → 100% | 0d → none |  | baseline start none → 2016-07-06; baseline finish none → 2016-07-08 |
| 18 | Clear and grub lot | 2017-08-08 → 2016-07-06 A (-398d) | 2017-08-08 → 2016-07-06 A (-398d) |  | 0% → 100% | 0d → none | 11, 12, 13, 14, 16, 15 → 11, 12, 13, 14, 16, 15, 8, 9 | baseline start none → 2016-07-06; baseline finish none → 2016-07-06 |
| 19 | Install temporary power service | 2017-08-09 → 2016-07-07 A (-398d) | 2017-08-09 → 2016-07-07 A (-398d) |  | 0% → 100% | 0d → none |  | baseline start none → 2016-07-07; baseline finish none → 2016-07-07 |
| 20 | Install underground utilities | 2017-08-10 → 2016-07-08 A (-398d) | 2017-08-10 → 2016-07-08 A (-398d) |  | 0% → 100% | 0d → none |  | baseline start none → 2016-07-08; baseline finish none → 2016-07-08 |
| 21 | **Foundation** | 2017-08-11 → 2016-07-11 A (-396d) | 2017-10-09 → 2016-08-17 A (-418d) | 42d → 27.5d | 0% → 100% | 0d → none |  | baseline start none → 2016-07-11; baseline finish none → 2016-08-17 |
| 22 | Excavate for foundations | 2017-08-11 → 2016-07-11 A (-396d) | 2017-08-15 → 2016-07-13 A (-398d) |  | 0% → 100% | 0d → none |  | baseline start none → 2016-07-11; baseline finish none → 2016-07-13 |
| 23 | Form basement walls | 2017-08-16 → 2016-07-14 A (-398d) | 2017-09-01 → 2016-07-22 A (-406d) | 13d → 6.5d | 0% → 100% | 0d → none |  | resources Concrete contractor → Concrete contractor [200%]; baseline start none → 2016-07-14; baseline finish none → 2016-07-22 |
| 24 | Place concrete for foundations & basement walls | 2017-09-04 → 2016-07-22 A (-409d) | 2017-09-19 → 2016-08-01 A (-414d) | 12d → 6d | 0% → 100% | 0d → none |  | resources Concrete contractor → Concrete contractor [200%]; baseline start none → 2016-07-22; baseline finish none → 2016-08-01 |
| 25 | Cure basement walls for 7 days | 2017-09-20 → 2016-08-01 A (-415d) | 2017-09-28 → 2016-08-10 A (-414d) |  | 0% → 100% | 0d → none |  | baseline start none → 2016-08-01; baseline finish none → 2016-08-10 |
| 26 | Strip basement wall forms | 2017-09-29 → 2016-08-10 A (-415d) | 2017-10-02 → 2016-08-11 A (-417d) | 2d → 1d | 0% → 100% | 0d → none |  | resources Concrete contractor → Concrete contractor [200%]; baseline start none → 2016-08-10; baseline finish none → 2016-08-11 |
| 27 | Waterproof/insulate basement walls | 2017-10-03 → 2016-08-11 A (-418d) | 2017-10-04 → 2016-08-12 A (-418d) | 2d → 1d | 0% → 100% | 0d → none |  | resources Concrete contractor → Concrete contractor [200%]; baseline start none → 2016-08-11; baseline finish none → 2016-08-12 |
| 28 | Perform foundation inspection | 2017-10-05 → 2016-08-12 A (-419d) | 2017-10-05 → 2016-08-15 A (-416d) |  | 0% → 100% | 0d → none |  | baseline start none → 2016-08-12; baseline finish none → 2016-08-15 |
| 29 | Backfill foundation | 2017-10-06 → 2016-08-15 A (-417d) | 2017-10-09 → 2016-08-17 A (-418d) |  | 0% → 100% | 0d → none |  | baseline start none → 2016-08-15; baseline finish none → 2016-08-17 |
| 30 | **Framing** | 2017-10-10 → 2016-08-17 A (-419d) | 2017-11-08 → 2016-09-26 (-408d) | 22d → 27.5d | 0% → 96% | 0d → -1d |  | baseline start none → 2016-08-17; baseline finish none → 2016-09-19 |
| 31 | Install 1st floor joists | 2017-10-10 → 2016-08-17 A (-419d) | 2017-10-11 → 2016-08-19 A (-418d) |  | 0% → 100% | 0d → none |  | baseline start none → 2016-08-17; baseline finish none → 2016-08-19 |
| 32 | Lay 1st floor decking | 2017-10-12 → 2016-08-19 A (-419d) | 2017-10-13 → 2016-08-23 A (-416d) |  | 0% → 100% | 0d → none |  | baseline start none → 2016-08-19; baseline finish none → 2016-08-23 |
| 33 | Frame 1st floor walls | 2017-10-16 → 2016-08-23 A (-419d) | 2017-10-19 → 2016-08-29 A (-416d) |  | 0% → 100% | 0d → none |  | baseline start none → 2016-08-23; baseline finish none → 2016-08-29 |
| 34 | Frame 1st floor corners | 2017-10-20 → 2016-08-29 A (-417d) | 2017-10-20 → 2016-08-30 A (-416d) |  | 0% → 100% | 0d → none |  | baseline start none → 2016-08-29; baseline finish none → 2016-08-30 |
| 35 | Install 2nd floor joists | 2017-10-23 → 2016-08-30 A (-419d) | 2017-10-24 → 2016-09-01 A (-418d) |  | 0% → 100% | 0d → none |  | baseline start none → 2016-08-30; baseline finish none → 2016-09-01 |
| 36 | Frame 2nd floor decking | 2017-10-25 → 2016-09-01 A (-419d) | 2017-10-26 → 2016-09-06 A (-415d) |  | 0% → 100% | 0d → none |  | baseline start none → 2016-09-01; baseline finish none → 2016-09-06 |
| 37 | Frame 2nd floor walls | 2017-10-27 → 2016-09-06 A (-416d) | 2017-10-31 → 2016-09-09 A (-417d) |  | 0% → 100% | 0d → none |  | baseline start none → 2016-09-06; baseline finish none → 2016-09-09 |
| 38 | Frame 2nd floor corners | 2017-11-01 → 2016-09-09 A (-418d) | 2017-11-02 → 2016-09-16 A (-412d) | 2d → 5.5d | 0% → 100% | 0d → none |  | baseline start none → 2016-09-09; baseline finish none → 2016-09-13 |
| 39 | Complete roof framing | 2017-11-03 → 2016-09-19 A (-410d) | 2017-11-07 → 2016-09-23 A (-410d) | 3d → 5d | 0% → 100% | 0d → none |  | baseline start none → 2016-09-13; baseline finish none → 2016-09-16 |
| 40 | Conduct framing inspection | 2017-11-08 → 2016-09-26 (-408d) | 2017-11-08 → 2016-09-26 (-408d) |  |  | 0d → -3.5d |  | baseline start none → 2016-09-16; baseline finish none → 2016-09-19 |
| 41 | **Dry In** | 2017-11-08 → 2016-09-26 (-408d) | 2017-12-07 → 2016-10-28 (-405d) | 22d → 25d |  | 0d → -4.5d |  | baseline start none → 2016-09-16; baseline finish none → 2016-10-20 |
| 42 | Install 1st floor sheathing | 2017-11-09 → 2016-09-27 (-408d) | 2017-11-13 → 2016-09-29 (-410d) |  |  | 0d → -3.5d |  | baseline start none → 2016-09-19; baseline finish none → 2016-09-22 |
| 43 | Install 2nd floor sheathing | 2017-11-14 → 2016-10-04 (-406d) | 2017-11-16 → 2016-10-06 (-406d) |  |  | 0d → -1.5d |  | baseline start none → 2016-09-26; baseline finish none → 2016-09-29 |
| 44 | Install roof decking | 2017-11-08 → 2016-09-26 (-408d) | 2017-11-10 → 2016-10-03 (-403d) |  |  | 4d → -1.5d |  | baseline start none → 2016-09-16; baseline finish none → 2016-09-26 |
| 45 | Install felt, flashing and shingles | 2017-11-24 → 2016-10-14 (-406d) | 2017-11-28 → 2016-10-18 (-406d) |  |  | 0d → -1.5d |  | baseline start none → 2016-10-06; baseline finish none → 2016-10-11 |
| 47 | Hang 1st floor exterior doors | 2017-11-29 → 2016-10-20 (-405d) | 2017-11-29 → 2016-10-20 (-405d) |  |  | 0d → -1.5d | 45 → 46 | baseline start none → 2016-10-11; baseline finish none → 2016-10-12 |
| 48 | Install 1st floor windows | 2017-11-30 → 2016-10-21 (-405d) | 2017-12-04 → 2016-10-25 (-405d) |  |  | 0d → -1.5d |  | baseline start none → 2016-10-12; baseline finish none → 2016-10-17 |
| 49 | Install 2nd floor windows | 2017-12-05 → 2016-10-26 (-405d) | 2017-12-07 → 2016-10-28 (-405d) |  |  | 0d → -1.5d |  | baseline start none → 2016-10-17; baseline finish none → 2016-10-20 |
| 50 | **Exterior Finishes** | 2017-12-08 → 2016-10-31 (-403d) | 2018-01-03 → 2016-11-29 (-400d) |  |  | 5d → -4.5d |  | baseline start none → 2016-10-20; baseline finish none → 2016-11-16 |
| 51 | Complete exterior brick | 2017-12-08 → 2016-10-31 (-403d) | 2017-12-29 → 2016-11-29 (-395d) |  |  | 5d → -4.5d |  | baseline start none → 2016-10-20; baseline finish none → 2016-11-11 |
| 52 | Complete exterior siding | 2018-01-01 → 2016-11-21 (-406d) | 2018-01-03 → 2016-11-23 (-406d) |  |  | 5d → none |  | baseline start none → 2016-11-14; baseline finish none → 2016-11-16 |
| 53 | **Utility Rough-ins and Complete Concrete** | 2017-11-13 → 2016-10-04 (-405d) | 2017-12-11 → 2016-11-01 (-405d) |  |  | 4d → -1.5d |  | was named Utility Rough-B97Ins and Complete Concrete; baseline start none → 2016-09-26; baseline finish none → 2016-11-01 |
| 54 | Rough-in plumbing | 2017-11-17 → 2016-10-07 (-406d) | 2017-11-23 → 2016-10-13 (-406d) |  |  | 0d → -1.5d |  | baseline start none → 2016-09-29; baseline finish none → 2016-10-06 |
| 55 | Conduct rough-in plumbing inspection | 2017-11-24 → 2016-10-14 (-406d) | 2017-11-24 → 2016-10-14 (-406d) |  |  | 20d → 25.5d |  | baseline start none → 2016-10-06; baseline finish none → 2016-10-07 |
| 56 | Place concrete for basement floor | 2017-11-27 → 2016-10-17 (-406d) | 2017-12-11 → 2016-10-24 (-413d) | 11d → 5.5d |  | 33d → 38d |  | resources Concrete contractor → Concrete contractor [200%]; baseline start none → 2016-10-07; baseline finish none → 2016-10-14 |
| 57 | Rough-in electrical | 2017-11-17 → 2016-10-07 (-406d) | 2017-11-23 → 2016-10-13 (-406d) |  |  | 6d → 12.5d |  | baseline start none → 2016-09-29; baseline finish none → 2016-10-06 |
| 58 | Conduct rough-in electrical inspection | 2017-11-24 → 2016-10-26 (-394d) | 2017-11-24 → 2016-10-26 (-394d) |  |  | 6d → 4.5d |  | constraint none → start no earlier than 2016-10-26; baseline start none → 2016-10-26; baseline finish none → 2016-10-26 |
| 59 | Rough-in HVAC | 2017-11-27 → 2016-10-27 (-396d) | 2017-11-29 → 2016-10-31 (-394d) |  |  | 6d → 4.5d |  | baseline start none → 2016-10-27; baseline finish none → 2016-10-31 |
| 60 | Conduct rough-in HVAC inspection | 2017-11-30 → 2016-11-01 (-394d) | 2017-11-30 → 2016-11-01 (-394d) |  |  | 24d → 21.5d |  | baseline start none → 2016-11-01; baseline finish none → 2016-11-01 |
| 61 | Rough-in communication - phone, cable, computer, alarm | 2017-11-13 → 2016-10-04 (-405d) | 2017-11-14 → 2016-10-05 (-405d) |  |  | 17d → 22.5d |  | baseline start none → 2016-09-26; baseline finish none → 2016-09-28 |
| 62 | **Interior Finishes** | 2017-12-08 → 2016-11-01 (-402d) | 2018-01-18 → 2016-12-14 (-400d) | 30d → 29d |  | 0d → 4.5d |  | baseline start none → 2016-11-01; baseline finish none → 2016-12-16 |
| 63 | **Insulation** | 2017-12-08 → 2016-11-01 (-402d) | 2017-12-22 → 2016-11-16 (-401d) | 11d → 11.5d |  | 0d → 4.5d |  | baseline start none → 2016-11-01; baseline finish none → 2016-11-16 |
| 64 | Place wall insulation - 1st floor | 2017-12-08 → 2016-11-01 (-402d) | 2017-12-08 → 2016-11-01 (-402d) |  |  | 0d → 4.5d |  | baseline start none → 2016-11-01; baseline finish none → 2016-11-01 |
| 65 | Place wall insulation - 2nd floor | 2017-12-11 → 2016-11-02 (-404d) | 2017-12-11 → 2016-11-02 (-404d) |  |  | 27d → 24.5d |  | baseline start none → 2016-11-02; baseline finish none → 2016-11-02 |
| 66 | Place ceiling insulation - 2nd floor | 2017-12-21 → 2016-11-15 (-401d) | 2017-12-21 → 2016-11-15 (-401d) |  |  | 24d → 21d |  | baseline start none → 2016-11-15; baseline finish none → 2016-11-15 |
| 67 | Conduct insulation inspection | 2017-12-22 → 2016-11-16 (-401d) | 2017-12-22 → 2016-11-16 (-401d) |  |  | 24d → 21d |  | baseline start none → 2016-11-16; baseline finish none → 2016-11-16 |
| 68 | **Drywall** | 2017-12-11 → 2016-11-02 (-404d) | 2017-12-21 → 2016-11-15 (-401d) | 9d → 9.5d |  | 0d → 4.5d |  | baseline start none → 2016-11-02; baseline finish none → 2016-11-15 |
| 69 | Install drywall - 1st floor walls | 2017-12-11 → 2016-11-02 (-404d) | 2017-12-12 → 2016-11-03 (-404d) |  |  | 0d → 4.5d |  | baseline start none → 2016-11-02; baseline finish none → 2016-11-03 |
| 70 | Install drywall - 1st floor overhead | 2017-12-13 → 2016-11-04 (-404d) | 2017-12-14 → 2016-11-07 (-402d) |  |  | 0d → 4.5d |  | baseline start none → 2016-11-04; baseline finish none → 2016-11-07 |
| 71 | Install drywall 2nd floor walls | 2017-12-15 → 2016-11-09 (-401d) | 2017-12-18 → 2016-11-10 (-403d) |  |  | 24d → 21d |  | baseline start none → 2016-11-09; baseline finish none → 2016-11-10 |
| 72 | Install drywall 2nd floor overhead | 2017-12-19 → 2016-11-11 (-403d) | 2017-12-20 → 2016-11-14 (-401d) |  |  | 24d → 21d |  | baseline start none → 2016-11-11; baseline finish none → 2016-11-14 |
| 73 | Tape and float 1st floor drywall | 2017-12-15 → 2016-11-08 (-402d) | 2017-12-15 → 2016-11-09 (-401d) |  |  | 0d → 4.5d |  | baseline start none → 2016-11-08; baseline finish none → 2016-11-09 |
| 74 | Tape and float 2nd floor drywall | 2017-12-21 → 2016-11-15 (-401d) | 2017-12-21 → 2016-11-15 (-401d) |  |  | 33d → 31.5d |  | baseline start none → 2016-11-15; baseline finish none → 2016-11-15 |
| 75 | **Paint and Wallpaper** | 2017-12-18 → 2016-11-09 (-404d) | 2018-01-09 → 2016-12-01 (-404d) | 17d → 14.5d |  | 0d → 4.5d |  | baseline start none → 2016-11-09; baseline finish none → 2016-11-22 |
| 76 | Texture all except entry and kitchen - 1st floor | 2017-12-18 → 2016-11-09 (-404d) | 2017-12-18 → 2016-11-10 (-403d) |  |  | 0d → 4.5d |  | baseline start none → 2016-11-09; baseline finish none → 2016-11-10 |
| 77 | Paint all - 1st floor | 2017-12-19 → 2016-11-10 (-404d) | 2017-12-19 → 2016-11-11 (-403d) |  |  | 0d → 4.5d |  | was named Paint all except entry and kitchen - 1st floor; baseline start none → 2016-11-10; baseline finish none → 2016-11-11 |

| ID | Task | Start | Finish | Duration | Total float | Predecessors | Other |
| --- | --- | --- | --- | --- | --- | --- | --- |
| 78 | Hang wallpaper entry and kitchen - 1st floor | 2017-12-20 → 2016-11-11 (-404d) | 2017-12-20 → 2016-11-14 (-401d) |  | 0d → 3.5d |  | baseline start none → 2016-11-11; baseline finish none → 2016-11-14 |
| 79 | Texture all - 2nd floor | 2017-12-19 → 2016-11-14 (-400d) | 2017-12-19 → 2016-11-15 (-399d) |  | 34d → 31d |  | baseline start none → 2016-11-14; baseline finish none → 2016-11-15 |
| 80 | Paint all - 2nd floor | 2017-12-20 → 2016-11-15 (-400d) | 2017-12-20 → 2016-11-16 (-399d) |  | 34d → 31d |  | baseline start none → 2016-11-15; baseline finish none → 2016-11-16 |
| 81 | Paint exterior siding & trim work | 2018-01-04 → 2016-11-28 (-402d) | 2018-01-09 → 2016-12-01 (-404d) |  | 5d → 0d |  | baseline start none → 2016-11-17; baseline finish none → 2016-11-22 |
| 82 | **Cabinets** | 2017-12-21 → 2016-11-11 (-405d) | 2017-12-28 → 2016-11-21 (-402d) |  | 0d → 4.5d |  | baseline start none → 2016-11-14; baseline finish none → 2016-11-22 |
| 83 | Install 1st floor - kitchen cabinets | 2017-12-21 → 2016-11-11 (-405d) | 2017-12-22 → 2016-11-15 (-402d) |  | 0d → 4.5d |  | baseline start none → 2016-11-14; baseline finish none → 2016-11-16 |
| 84 | Install 1st floor - master bath and guest cabinets | 2017-12-25 → 2016-11-15 (-405d) | 2017-12-25 → 2016-11-16 (-404d) |  | 0d → 4.5d |  | baseline start none → 2016-11-16; baseline finish none → 2016-11-17 |
| 85 | Install 2nd floor - hall bath and private bath cabinets | 2017-12-26 → 2016-11-16 (-405d) | 2017-12-26 → 2016-11-17 (-404d) |  | 1d → 5.5d |  | baseline start none → 2016-11-17; baseline finish none → 2016-11-18 |
| 86 | Install chair rails, crown moldings, trim | 2017-12-27 → 2016-11-17 (-405d) | 2017-12-28 → 2016-11-21 (-402d) |  | 20d → 18.5d |  | baseline start none → 2016-11-18; baseline finish none → 2016-11-22 |
| 87 | **Finish Plumbing** | 2017-12-25 → 2016-11-15 (-405d) | 2018-01-01 → 2016-11-23 (-404d) |  | 0d → 4.5d |  | baseline start none → 2016-11-16; baseline finish none → 2016-11-28 |
| 88 | Complete 1st floor - kitchen plumbing | 2017-12-25 → 2016-11-15 (-405d) | 2017-12-25 → 2016-11-16 (-404d) |  | 0d → 4.5d |  | baseline start none → 2016-11-16; baseline finish none → 2016-11-17 |
| 89 | Complete 1st floor - master bath and guest plumbing | 2017-12-26 → 2016-11-16 (-405d) | 2017-12-27 → 2016-11-18 (-404d) |  | 0d → 4.5d |  | baseline start none → 2016-11-17; baseline finish none → 2016-11-21 |
| 90 | Complete 2nd floor - hall bath and private bath plumbing | 2017-12-28 → 2016-11-18 (-405d) | 2017-12-29 → 2016-11-22 (-402d) |  | 0d → 4.5d |  | baseline start none → 2016-11-21; baseline finish none → 2016-11-23 |
| 91 | Conduct finish plumbing inspection | 2018-01-01 → 2016-11-22 (-405d) | 2018-01-01 → 2016-11-23 (-404d) |  | 0d → 4.5d |  | baseline start none → 2016-11-23; baseline finish none → 2016-11-28 |
| 92 | **Finish Electrical** | 2018-01-01 → 2016-11-22 (-405d) | 2018-01-03 → 2016-11-30 (-399d) | 3d → 4d | 1d → 4.5d |  | baseline start none → 2016-11-23; baseline finish none → 2016-12-06 |
| 93 | Complete 1st floor circuits to service panel | 2018-01-01 → 2016-11-22 (-405d) | 2018-01-01 → 2016-11-23 (-404d) |  | 3d → 4.5d |  | baseline start none → 2016-11-23; baseline finish none → 2016-11-28 |
| 94 | Complete 2nd floor circuits to service panel | 2018-01-02 → 2016-11-28 (-400d) | 2018-01-02 → 2016-11-29 (-399d) |  | 3d → 6.5d |  | baseline start none → 2016-12-05; baseline finish none → 2016-12-05 |
| 95 | Conduct finish electrical inspection | 2018-01-03 → 2016-11-29 (-400d) | 2018-01-03 → 2016-11-30 (-399d) |  | 3d → 6.5d |  | baseline start none → 2016-12-06; baseline finish none → 2016-12-06 |
| 96 | Complete communications wiring - phone, cable, computer, alarm | 2018-01-02 → 2016-11-23 (-405d) | 2018-01-03 → 2016-11-29 (-400d) |  | 0d → 4.5d |  | baseline start none → 2016-11-28; baseline finish none → 2016-11-30 |
| 97 | **Finish HVAC** | 2018-01-04 → 2016-11-29 (-401d) | 2018-01-08 → 2016-12-02 (-402d) |  | 0d → 4.5d |  | baseline start none → 2016-11-30; baseline finish none → 2016-12-05 |
| 98 | Complete 1st floor - zone 1 HVAC | 2018-01-04 → 2016-11-29 (-401d) | 2018-01-04 → 2016-11-30 (-400d) |  | 0d → 4.5d |  | baseline start none → 2016-11-30; baseline finish none → 2016-12-01 |
| 99 | Complete 2nd floor - zone 2 HVAC | 2018-01-05 → 2016-11-30 (-401d) | 2018-01-05 → 2016-12-01 (-400d) |  | 0d → 4.5d |  | baseline start none → 2016-12-01; baseline finish none → 2016-12-02 |
| 100 | Conduct HVAC inspection | 2018-01-08 → 2016-12-01 (-403d) | 2018-01-08 → 2016-12-02 (-402d) |  | 0d → 4.5d |  | baseline start none → 2016-12-02; baseline finish none → 2016-12-05 |
| 101 | **Carpet, Tile and Appliances** | 2018-01-09 → 2016-12-02 (-403d) | 2018-01-18 → 2016-12-14 (-400d) |  | 0d → 4.5d |  | baseline start none → 2016-12-07; baseline finish none → 2016-12-16 |
| 102 | Tile entry, kitchen and baths | 2018-01-09 → 2016-12-02 (-403d) | 2018-01-11 → 2016-12-07 (-400d) |  | 0d → 4.5d |  | baseline start none → 2016-12-07; baseline finish none → 2016-12-09 |
| 103 | Carpet 1st floor | 2018-01-12 → 2016-12-07 (-401d) | 2018-01-15 → 2016-12-09 (-402d) |  | 0d → 4.5d |  | baseline start none → 2016-12-12; baseline finish none → 2016-12-13 |
| 104 | Carpet 2nd floor | 2018-01-16 → 2016-12-09 (-403d) | 2018-01-17 → 2016-12-13 (-400d) |  | 0d → 4.5d |  | baseline start none → 2016-12-14; baseline finish none → 2016-12-15 |
| 105 | Install appliances | 2018-01-18 → 2016-12-13 (-401d) | 2018-01-18 → 2016-12-14 (-400d) |  | 0d → 4.5d |  | baseline start none → 2016-12-16; baseline finish none → 2016-12-16 |
| 106 | **Landscaping and Grounds Work** | 2018-01-10 → 2016-12-02 (-404d) | 2018-01-25 → 2016-12-21 (-400d) | 12d → 14d |  |  | baseline start none → 2016-11-23; baseline finish none → 2016-12-14 |
| 107 | Pour concrete driveway and sidewalks | 2018-01-10 → 2016-12-02 (-404d) | 2018-01-11 → 2016-12-02 (-405d) | 2d → 1d | 5d → 0d |  | resources Concrete contractor → Concrete contractor [200%]; baseline start none → 2016-11-23; baseline finish none → 2016-11-23 |
| 108 | Install backyard fence | 2018-01-19 → 2016-12-05 (-410d) | 2018-01-22 → 2016-12-06 (-412d) |  |  | 105, 107 → 107 | baseline start none → 2016-11-28; baseline finish none → 2016-11-29 |
| 115 | **Final Acceptance** | 2018-01-26 → 2016-12-02 (-420d) | 2018-02-06 → 2016-12-30 (-403d) | 8d → 19.5d |  |  | baseline start none → 2016-12-07; baseline finish none → 2016-12-28 |
| 116 | Complete final inspection for certificate of occupancy | 2018-01-26 → 2016-12-02 (-420d) | 2018-01-26 → 2016-12-05 (-417d) |  | 0d → 11.5d | Sod and complete plantings - backyard, 100, 95, 91, 67, 86, 56 → 100, 95, 91, 67, 86, 56 | baseline start none → 2016-12-07; baseline finish none → 2016-12-07 |
| 117 | Cleanup for occupancy | 2018-01-29 → 2016-12-21 (-404d) | 2018-01-29 → 2016-12-21 (-404d) |  |  | 105, 116 → 105, 116, 113 | baseline start none → 2016-12-19; baseline finish none → 2016-12-19 |
| 118 | Perform final walk-through inspection | 2018-01-30 → 2016-12-22 (-404d) | 2018-01-30 → 2016-12-22 (-404d) |  |  |  | baseline start none → 2016-12-20; baseline finish none → 2016-12-20 |
| 119 | Complete punch list items | 2018-01-31 → 2016-12-23 (-404d) | 2018-02-06 → 2016-12-30 (-403d) |  |  |  | baseline start none → 2016-12-21; baseline finish none → 2016-12-28 |

## Version 3 (data date 2016-09-23, saved 2016-02-08, file BWH_Resource_Pool.mpp)

Last finish stays 2016-12-30. Complete tasks 33 → 0.

Changed:

| ID | Task | Start | Finish | Duration | Complete | Total float | Other |
| --- | --- | --- | --- | --- | --- | --- | --- |
| 1 | **General Conditions** | 2016-05-02 A → 2016-05-02 | 2016-07-05 A → 2016-07-05 |  | 100% → 0% | none → -4.5d | baseline start 2016-05-02 → none; baseline finish 2016-07-05 → none |
| 2 | Finalize plans and develop estimate with owner, architect | 2016-05-02 A → 2016-05-02 | 2016-05-13 A → 2016-05-13 |  | 100% → 0% | none → 0d | baseline start 2016-05-02 → none; baseline finish 2016-05-13 → none |
| 3 | Sign contract and notice to proceed | 2016-05-16 A → 2016-05-16 | 2016-05-16 A → 2016-05-16 |  | 100% → 0% | none → 0d | baseline start 2016-05-16 → none; baseline finish 2016-05-16 → none |
| 4 | **Clear Old Home** | 2016-06-01 A → 2016-06-01 | 2016-07-05 A → 2016-07-05 |  | 100% → 0% | none → -4.5d | baseline start 2016-06-01 → none; baseline finish 2016-07-05 → none |
| 5 | Demolition of Old House | 2016-06-01 A → 2016-06-01 | 2016-06-14 A → 2016-06-14 |  | 100% → 0% | none → 7.5d | baseline start 2016-06-01 → none; baseline finish 2016-06-14 → none |
| 6 | Place Containers | 2016-06-01 A → 2016-06-01 | 2016-06-01 A → 2016-06-01 |  | 100% → 0% | none → 11.44d | baseline start 2016-06-01 → none; baseline finish 2016-06-01 → none |
| 7 | Sort Debris | 2016-06-09 A → 2016-06-07 (-2d) | 2016-06-17 A → 2016-06-15 (-2d) |  | 100% → 0% | none → 7.5d | baseline start 2016-06-09 → none; baseline finish 2016-06-15 → none |
| 8 | Haul Recycling | 2016-07-05 A → 2016-07-05 | 2016-07-05 A → 2016-07-05 |  | 100% → 0% | none → -4.5d | baseline start 2016-07-05 → none; baseline finish 2016-07-05 → none |
| 9 | Haul Waste | 2016-06-17 A → 2016-06-16 (-1d) | 2016-06-20 A → 2016-06-16 (-4d) |  | 100% → 0% | none → 7.5d | baseline start 2016-06-16 → none; baseline finish 2016-06-16 → none |
| 10 | **Apply for Permits** | 2016-05-16 A → 2016-05-16 | 2016-05-27 A → 2016-05-16 (-11d) | 9d → 0d | 100% → 0% | none → 0d | baseline start 2016-05-16 → none; baseline finish 2016-05-16 → none |
| 11 | Secure foundation permit | 2016-05-16 A → 2016-05-16 | 2016-05-27 A → 2016-05-16 (-11d) |  | 100% → 0% | none → 0d | baseline start 2016-05-16 → none; baseline finish 2016-05-16 → none |
| 12 | Secure framing permit | 2016-05-16 A → 2016-05-16 | 2016-05-27 A → 2016-05-16 (-11d) |  | 100% → 0% | none → 0d | baseline start 2016-05-16 → none; baseline finish 2016-05-16 → none |
| 13 | Secure electrical permit | 2016-05-16 A → 2016-05-16 | 2016-05-27 A → 2016-05-16 (-11d) |  | 100% → 0% | none → 0d | baseline start 2016-05-16 → none; baseline finish 2016-05-16 → none |
| 14 | Secure plumbing permit | 2016-05-16 A → 2016-05-16 | 2016-05-27 A → 2016-05-16 (-11d) |  | 100% → 0% | none → 0d | baseline start 2016-05-16 → none; baseline finish 2016-05-16 → none |
| 15 | Secure HVAC permit | 2016-05-16 A → 2016-05-16 | 2016-05-27 A → 2016-05-16 (-11d) |  | 100% → 0% | none → 0d | baseline start 2016-05-16 → none; baseline finish 2016-05-16 → none |
| 16 | Secure miscellaneous permits | 2016-05-16 A → 2016-05-16 | 2016-05-27 A → 2016-05-16 (-11d) |  | 100% → 0% | none → 0d | baseline start 2016-05-16 → none; baseline finish 2016-05-16 → none |
| 17 | **Site Work** | 2016-07-06 A → 2016-07-06 | 2016-07-08 A → 2016-07-08 |  | 100% → 0% | none → -4.5d | baseline start 2016-07-06 → none; baseline finish 2016-07-08 → none |
| 18 | Clear and grub lot | 2016-07-06 A → 2016-07-06 | 2016-07-06 A → 2016-07-06 |  | 100% → 0% | none → -4.5d | baseline start 2016-07-06 → none; baseline finish 2016-07-06 → none |
| 19 | Install temporary power service | 2016-07-07 A → 2016-07-07 | 2016-07-07 A → 2016-07-07 |  | 100% → 0% | none → -4.5d | baseline start 2016-07-07 → none; baseline finish 2016-07-07 → none |
| 20 | Install underground utilities | 2016-07-08 A → 2016-07-08 | 2016-07-08 A → 2016-07-08 |  | 100% → 0% | none → -4.5d | baseline start 2016-07-08 → none; baseline finish 2016-07-08 → none |
| 21 | **Foundation** | 2016-07-11 A → 2016-07-11 | 2016-08-17 A → 2016-08-17 |  | 100% → 0% | none → -4.5d | baseline start 2016-07-11 → none; baseline finish 2016-08-17 → none |
| 22 | Excavate for foundations | 2016-07-11 A → 2016-07-11 | 2016-07-13 A → 2016-07-13 |  | 100% → 0% | none → -4.5d | baseline start 2016-07-11 → none; baseline finish 2016-07-13 → none |
| 23 | Form basement walls | 2016-07-14 A → 2016-07-14 | 2016-07-22 A → 2016-07-22 |  | 100% → 0% | none → -4.5d | baseline start 2016-07-14 → none; baseline finish 2016-07-22 → none |
| 24 | Place concrete for foundations & basement walls | 2016-07-22 A → 2016-07-22 | 2016-08-01 A → 2016-08-01 |  | 100% → 0% | none → -4.5d | baseline start 2016-07-22 → none; baseline finish 2016-08-01 → none |
| 25 | Cure basement walls for 7 days | 2016-08-01 A → 2016-08-01 | 2016-08-10 A → 2016-08-10 |  | 100% → 0% | none → -4.5d | baseline start 2016-08-01 → none; baseline finish 2016-08-10 → none |
| 26 | Strip basement wall forms | 2016-08-10 A → 2016-08-10 | 2016-08-11 A → 2016-08-11 |  | 100% → 0% | none → -4.5d | baseline start 2016-08-10 → none; baseline finish 2016-08-11 → none |
| 27 | Waterproof/insulate basement walls | 2016-08-11 A → 2016-08-11 | 2016-08-12 A → 2016-08-12 |  | 100% → 0% | none → -4.5d | baseline start 2016-08-11 → none; baseline finish 2016-08-12 → none |
| 28 | Perform foundation inspection | 2016-08-12 A → 2016-08-12 | 2016-08-15 A → 2016-08-15 |  | 100% → 0% | none → -4.5d | baseline start 2016-08-12 → none; baseline finish 2016-08-15 → none |
| 29 | Backfill foundation | 2016-08-15 A → 2016-08-15 | 2016-08-17 A → 2016-08-17 |  | 100% → 0% | none → -4.5d | baseline start 2016-08-15 → none; baseline finish 2016-08-17 → none |
| 30 | **Framing** | 2016-08-17 A → 2016-08-17 |  |  | 96% → 0% | -1d → -4.5d | baseline start 2016-08-17 → none; baseline finish 2016-09-19 → none |
| 31 | Install 1st floor joists | 2016-08-17 A → 2016-08-17 | 2016-08-19 A → 2016-08-19 |  | 100% → 0% | none → -4.5d | baseline start 2016-08-17 → none; baseline finish 2016-08-19 → none |
| 32 | Lay 1st floor decking | 2016-08-19 A → 2016-08-19 | 2016-08-23 A → 2016-08-23 |  | 100% → 0% | none → -4.5d | baseline start 2016-08-19 → none; baseline finish 2016-08-23 → none |
| 33 | Frame 1st floor walls | 2016-08-23 A → 2016-08-23 | 2016-08-29 A → 2016-08-29 |  | 100% → 0% | none → -4.5d | baseline start 2016-08-23 → none; baseline finish 2016-08-29 → none |
| 34 | Frame 1st floor corners | 2016-08-29 A → 2016-08-29 | 2016-08-30 A → 2016-08-30 |  | 100% → 0% | none → -4.5d | baseline start 2016-08-29 → none; baseline finish 2016-08-30 → none |
| 35 | Install 2nd floor joists | 2016-08-30 A → 2016-08-30 | 2016-09-01 A → 2016-09-01 |  | 100% → 0% | none → -4.5d | baseline start 2016-08-30 → none; baseline finish 2016-09-01 → none |
| 36 | Frame 2nd floor decking | 2016-09-01 A → 2016-09-01 | 2016-09-06 A → 2016-09-06 |  | 100% → 0% | none → -4.5d | baseline start 2016-09-01 → none; baseline finish 2016-09-06 → none |
| 37 | Frame 2nd floor walls | 2016-09-06 A → 2016-09-06 | 2016-09-09 A → 2016-09-09 |  | 100% → 0% | none → -4.5d | baseline start 2016-09-06 → none; baseline finish 2016-09-09 → none |
| 38 | Frame 2nd floor corners | 2016-09-09 A → 2016-09-09 | 2016-09-16 A → 2016-09-16 |  | 100% → 0% | none → -4.5d | baseline start 2016-09-09 → none; baseline finish 2016-09-13 → none |
| 39 | Complete roof framing | 2016-09-19 A → 2016-09-19 | 2016-09-23 A → 2016-09-23 |  | 100% → 0% | none → -4.5d | baseline start 2016-09-13 → none; baseline finish 2016-09-16 → none |
| 40 | Conduct framing inspection |  |  |  |  | -3.5d → -4.5d | baseline start 2016-09-16 → none; baseline finish 2016-09-19 → none |
| 41 | **Dry In** |  |  |  |  |  | baseline start 2016-09-16 → none; baseline finish 2016-10-20 → none |
| 42 | Install 1st floor sheathing |  |  |  |  | -3.5d → -4.5d | baseline start 2016-09-19 → none; baseline finish 2016-09-22 → none |
| 43 | Install 2nd floor sheathing |  |  |  |  | -1.5d → -4.5d | baseline start 2016-09-26 → none; baseline finish 2016-09-29 → none |
| 44 | Install roof decking |  |  |  |  |  | baseline start 2016-09-16 → none; baseline finish 2016-09-26 → none |
| 45 | Install felt, flashing and shingles |  |  |  |  | -1.5d → -4.5d | baseline start 2016-10-06 → none; baseline finish 2016-10-11 → none |
| 47 | Hang 1st floor exterior doors |  |  |  |  | -1.5d → -4.5d | baseline start 2016-10-11 → none; baseline finish 2016-10-12 → none |
| 48 | Install 1st floor windows |  |  |  |  | -1.5d → -4.5d | baseline start 2016-10-12 → none; baseline finish 2016-10-17 → none |
| 49 | Install 2nd floor windows |  |  |  |  | -1.5d → -4.5d | baseline start 2016-10-17 → none; baseline finish 2016-10-20 → none |
| 50 | **Exterior Finishes** |  |  |  |  |  | baseline start 2016-10-20 → none; baseline finish 2016-11-16 → none |
| 51 | Complete exterior brick |  |  |  |  |  | baseline start 2016-10-20 → none; baseline finish 2016-11-11 → none |
| 52 | Complete exterior siding |  |  |  |  |  | baseline start 2016-11-14 → none; baseline finish 2016-11-16 → none |
| 53 | **Utility Rough-ins and Complete Concrete** |  |  |  |  |  | baseline start 2016-09-26 → none; baseline finish 2016-11-01 → none |
| 54 | Rough-in plumbing |  |  |  |  | -1.5d → -4.5d | baseline start 2016-09-29 → none; baseline finish 2016-10-06 → none |
| 55 | Conduct rough-in plumbing inspection |  |  |  |  |  | baseline start 2016-10-06 → none; baseline finish 2016-10-07 → none |
| 56 | Place concrete for basement floor |  |  |  |  |  | baseline start 2016-10-07 → none; baseline finish 2016-10-14 → none |
| 57 | Rough-in electrical |  |  |  |  |  | baseline start 2016-09-29 → none; baseline finish 2016-10-06 → none |
| 58 | Conduct rough-in electrical inspection |  |  |  |  |  | baseline start 2016-10-26 → none; baseline finish 2016-10-26 → none |
| 59 | Rough-in HVAC |  |  |  |  |  | baseline start 2016-10-27 → none; baseline finish 2016-10-31 → none |
| 60 | Conduct rough-in HVAC inspection |  |  |  |  |  | baseline start 2016-11-01 → none; baseline finish 2016-11-01 → none |
| 61 | Rough-in communication - phone, cable, computer, alarm |  |  |  |  |  | baseline start 2016-09-26 → none; baseline finish 2016-09-28 → none |
| 62 | **Interior Finishes** |  |  |  |  |  | baseline start 2016-11-01 → none; baseline finish 2016-12-16 → none |
| 63 | **Insulation** |  |  |  |  |  | baseline start 2016-11-01 → none; baseline finish 2016-11-16 → none |
| 64 | Place wall insulation - 1st floor |  |  |  |  |  | baseline start 2016-11-01 → none; baseline finish 2016-11-01 → none |
| 65 | Place wall insulation - 2nd floor |  |  |  |  |  | baseline start 2016-11-02 → none; baseline finish 2016-11-02 → none |
| 66 | Place ceiling insulation - 2nd floor |  |  |  |  |  | baseline start 2016-11-15 → none; baseline finish 2016-11-15 → none |
| 67 | Conduct insulation inspection |  |  |  |  |  | baseline start 2016-11-16 → none; baseline finish 2016-11-16 → none |
| 68 | **Drywall** |  |  |  |  |  | baseline start 2016-11-02 → none; baseline finish 2016-11-15 → none |
| 69 | Install drywall - 1st floor walls |  |  |  |  |  | baseline start 2016-11-02 → none; baseline finish 2016-11-03 → none |
| 70 | Install drywall - 1st floor overhead |  |  |  |  |  | baseline start 2016-11-04 → none; baseline finish 2016-11-07 → none |
| 71 | Install drywall 2nd floor walls |  |  |  |  |  | baseline start 2016-11-09 → none; baseline finish 2016-11-10 → none |

| ID | Task | Total float | Other |
| --- | --- | --- | --- |
| 72 | Install drywall 2nd floor overhead |  | baseline start 2016-11-11 → none; baseline finish 2016-11-14 → none |
| 73 | Tape and float 1st floor drywall |  | baseline start 2016-11-08 → none; baseline finish 2016-11-09 → none |
| 74 | Tape and float 2nd floor drywall | 31.5d → 30d | baseline start 2016-11-15 → none; baseline finish 2016-11-15 → none |
| 75 | **Paint and Wallpaper** |  | baseline start 2016-11-09 → none; baseline finish 2016-11-22 → none |
| 76 | Texture all except entry and kitchen - 1st floor |  | baseline start 2016-11-09 → none; baseline finish 2016-11-10 → none |
| 77 | Paint all - 1st floor |  | baseline start 2016-11-10 → none; baseline finish 2016-11-11 → none |
| 78 | Hang wallpaper entry and kitchen - 1st floor |  | baseline start 2016-11-11 → none; baseline finish 2016-11-14 → none |
| 79 | Texture all - 2nd floor | 31d → 29.5d | baseline start 2016-11-14 → none; baseline finish 2016-11-15 → none |
| 80 | Paint all - 2nd floor | 31d → 29.5d | baseline start 2016-11-15 → none; baseline finish 2016-11-16 → none |
| 81 | Paint exterior siding & trim work |  | baseline start 2016-11-17 → none; baseline finish 2016-11-22 → none |
| 82 | **Cabinets** |  | baseline start 2016-11-14 → none; baseline finish 2016-11-22 → none |
| 83 | Install 1st floor - kitchen cabinets |  | baseline start 2016-11-14 → none; baseline finish 2016-11-16 → none |
| 84 | Install 1st floor - master bath and guest cabinets |  | baseline start 2016-11-16 → none; baseline finish 2016-11-17 → none |
| 85 | Install 2nd floor - hall bath and private bath cabinets |  | baseline start 2016-11-17 → none; baseline finish 2016-11-18 → none |
| 86 | Install chair rails, crown moldings, trim |  | baseline start 2016-11-18 → none; baseline finish 2016-11-22 → none |
| 87 | **Finish Plumbing** |  | baseline start 2016-11-16 → none; baseline finish 2016-11-28 → none |
| 88 | Complete 1st floor - kitchen plumbing |  | baseline start 2016-11-16 → none; baseline finish 2016-11-17 → none |
| 89 | Complete 1st floor - master bath and guest plumbing |  | baseline start 2016-11-17 → none; baseline finish 2016-11-21 → none |
| 90 | Complete 2nd floor - hall bath and private bath plumbing |  | baseline start 2016-11-21 → none; baseline finish 2016-11-23 → none |
| 91 | Conduct finish plumbing inspection |  | baseline start 2016-11-23 → none; baseline finish 2016-11-28 → none |
| 92 | **Finish Electrical** |  | baseline start 2016-11-23 → none; baseline finish 2016-12-06 → none |
| 93 | Complete 1st floor circuits to service panel |  | baseline start 2016-11-23 → none; baseline finish 2016-11-28 → none |
| 94 | Complete 2nd floor circuits to service panel |  | baseline start 2016-12-05 → none; baseline finish 2016-12-05 → none |
| 95 | Conduct finish electrical inspection |  | baseline start 2016-12-06 → none; baseline finish 2016-12-06 → none |
| 96 | Complete communications wiring - phone, cable, computer, alarm |  | baseline start 2016-11-28 → none; baseline finish 2016-11-30 → none |
| 97 | **Finish HVAC** |  | baseline start 2016-11-30 → none; baseline finish 2016-12-05 → none |
| 98 | Complete 1st floor - zone 1 HVAC |  | baseline start 2016-11-30 → none; baseline finish 2016-12-01 → none |
| 99 | Complete 2nd floor - zone 2 HVAC |  | baseline start 2016-12-01 → none; baseline finish 2016-12-02 → none |
| 100 | Conduct HVAC inspection |  | baseline start 2016-12-02 → none; baseline finish 2016-12-05 → none |
| 101 | **Carpet, Tile and Appliances** |  | baseline start 2016-12-07 → none; baseline finish 2016-12-16 → none |
| 102 | Tile entry, kitchen and baths |  | baseline start 2016-12-07 → none; baseline finish 2016-12-09 → none |
| 103 | Carpet 1st floor |  | baseline start 2016-12-12 → none; baseline finish 2016-12-13 → none |
| 104 | Carpet 2nd floor |  | baseline start 2016-12-14 → none; baseline finish 2016-12-15 → none |
| 105 | Install appliances |  | baseline start 2016-12-16 → none; baseline finish 2016-12-16 → none |
| 106 | **Landscaping and Grounds Work** |  | baseline start 2016-11-23 → none; baseline finish 2016-12-14 → none |
| 107 | Pour concrete driveway and sidewalks |  | baseline start 2016-11-23 → none; baseline finish 2016-11-23 → none |
| 108 | Install backyard fence |  | baseline start 2016-11-28 → none; baseline finish 2016-11-29 → none |
| 109 | Order Plants and Trees |  | baseline start 2016-11-30 → none; baseline finish 2016-11-30 → none |
| 110 | Build Compost Bin |  | baseline start 2016-12-01 → none; baseline finish 2016-12-01 → none |
| 111 | Build Flower Beds and Edges |  | baseline start 2016-12-05 → none; baseline finish 2016-12-06 → none |
| 112 | Weed and Trim Existing Yard |  | baseline start 2016-12-07 → none; baseline finish 2016-12-08 → none |
| 113 | Plant New Plants and Trees |  | baseline start 2016-12-12 → none; baseline finish 2016-12-13 → none |
| 114 | Re-Seed Bare Lawn Areas |  | baseline start 2016-12-14 → none; baseline finish 2016-12-14 → none |
| 115 | **Final Acceptance** |  | baseline start 2016-12-07 → none; baseline finish 2016-12-28 → none |
| 116 | Complete final inspection for certificate of occupancy |  | baseline start 2016-12-07 → none; baseline finish 2016-12-07 → none |
| 117 | Cleanup for occupancy |  | baseline start 2016-12-19 → none; baseline finish 2016-12-19 → none |
| 118 | Perform final walk-through inspection |  | baseline start 2016-12-20 → none; baseline finish 2016-12-20 → none |
| 119 | Complete punch list items |  | baseline start 2016-12-21 → none; baseline finish 2016-12-28 → none |
| 120 | Ready for Move-In |  | baseline start 2016-12-28 → none; baseline finish 2016-12-28 → none |
